# 08-06-01_Terminplanung

Schedule from MS Project, 2016-01-06 to 2016-02-29, costs in €.

## Calendars

- Standard: Mon-Fri 08:00-12:00, 13:00-17:00; Sat-Sun off.

## Resources

| Resource | Rate |
| --- | --- |
| Einkäufer | 60 |
| Mechaniker | 40 |
| Monteur | 70 |
| Projektleiter | 80 |
| Fräsmaschine | 65 |
| Hobelbank | 64 |
| Drehbank | 66 |
| Bohrmaschine | 62 |
| Kühlmittel | 14 |
| Büromaterial |  |

## Schedule

| ID | Task | Type | Duration | Start | Finish | Predecessors | Baseline start | Baseline finish | Baseline duration | Total slack | Free slack | Constraint | Resources | Work | Cost | Baseline cost |
| --- | --- | --- | --- | --- | --- | --- | --- | --- | --- | --- | --- | --- | --- | --- | --- | --- |
| 1 | Start | milestone | 0d | 2016-01-06 | 2016-01-06 |  | 2016-01-06 | 2016-01-06 | 0d | 2d | 0d | start no earlier than 2016-01-06 |  |  |  |  |
| 2 | Materiallieferung |  | 4d | 2016-01-06 | 2016-01-15 | 1 | 2016-01-06 | 2016-01-15 | 6d | 3d | 0d |  | Projektleiter [2%]; Einkäufer [60%]; Büromaterial [0.1%] | 14.88h | 902.4 | 902.4 |
| 3 | Bauteil C |  | 5d | 2016-01-08 | 2016-01-14 | 1 | 2016-01-06 | 2016-01-12 | 5d | 0d |  | start no earlier than 2016-01-08 | Einkäufer [60%]; Projektleiter [2%]; Büromaterial [0.1%] | 24.8h | 1,504 | 1,504 |
| 4 | Bauteil A fräsen |  | 8d | 2016-01-18 | 2016-02-01 | 2 | 2016-01-18 | 2016-02-01 | 8d | 14d | 0d |  | Projektleiter [5%]; Mechaniker [80%]; Fräsmaschine; Büromaterial [0.1%] | 59.2h | 3,244 | 3,244 |
| 5 | Bauteil B hobeln |  | 11d | 2016-01-18 | 2016-02-15 | 2 | 2016-01-18 | 2016-02-10 | 9d | 3d |  |  | Projektleiter [5%]; Mechaniker [80%]; Hobelbank; Büromaterial [0.1%] | 103.6h | 5,612 | 5,612 |
| 6 | Bauteil C drehen |  | 8d | 2016-01-15 | 2016-02-18 | 3 | 2016-01-13 | 2016-02-16 | 8d | 0d |  |  | Projektleiter [5%]; Mechaniker [80%]; Drehbank; Büromaterial [0.1%] | 59.2h | 3,276 | 3,276 |
| 7 | Bauteil D | milestone | 0d | 2016-01-14 | 2016-01-14 | 3 |  |  |  | 1d | 0d | start no earlier than 2016-01-11 |  |  |  |  |
| 8 | Bauteil D bohren |  | 5d | 2016-01-15 | 2016-01-21 | 7 | 2016-01-13 | 2016-01-19 | 5d | 1d |  | finish no later than 2016-01-23 | Projektleiter [5%]; Bohrmaschine; Büromaterial [0.1%] | 42h | 2,652 | 3,932 |
| 9 | Bauteil A bohren |  | 5d | 2016-02-02 | 2016-02-08 | 4 | 2016-02-02 | 2016-02-08 | 5d | 14d |  |  | Projektleiter [5%]; Mechaniker [80%]; Bohrmaschine; Büromaterial [0.1%] | 74h | 3,932 | 3,932 |
| 10 | Gruppe montieren |  | 6d | 2016-02-19 | 2016-02-26 | 5, 6 | 2016-02-17 | 2016-02-24 | 6d | 0d |  |  | Projektleiter [1%]; Monteur; Kühlmittel; Büromaterial [0.1%] | 48.48h | 3,412.4 | 3,412.4 |
| 11 | Produkt montieren |  | 1d | 2016-02-29 | 2016-02-29 | 8, 9, 10 | 2016-02-25 | 2016-02-25 | 1d | 0d |  |  | Projektleiter [1%]; Monteur; Kühlmittel; Büromaterial [0.1%] | 8.08h | 580.4 | 580.4 |
