# 08-07-02_Interaktion

Schedule from MS Project, 2016-01-08 to 2016-02-29, costs in €, A marks actual dates.

## Calendars

- Standard: Mon-Fri 08:00-12:00, 13:00-17:00; Sat-Sun off.

## Resources

| Resource | Rate |
| --- | --- |
| Einkäufer | 60 |
| Mechaniker | 40 |
| Monteur | 70 |
| Projektleiter | 80 |
| Fräsmaschine | 65 |
| Hobelbank | 64 |
| Drehbank | 66 |
| Bohrmaschine | 62 |
| Kühlmittel | 12 |
| Schmiermittel | 14 |
| Büromaterial |  |

## Schedule

| ID | Task | Type | Duration | Start | Finish | Predecessors | Complete | Remaining | Total slack | Free slack | Constraint | Resources | Work | Actual work | Cost | Actual cost |
| --- | --- | --- | --- | --- | --- | --- | --- | --- | --- | --- | --- | --- | --- | --- | --- | --- |
| 1 | Start | milestone | 0d | 2016-01-08 | 2016-01-08 |  |  |  | 37d |  | start no earlier than 2016-01-08 |  |  |  |  |  |
| 2 | Materiallieferung |  | 6d | 2016-01-08 A | 2016-01-19 A | 1 | 100% |  |  |  |  | Einkäufer [60%]; Projektleiter [2%]; Büromaterial [0.1%] | 14.88h | 14.88h | 902.4 | 902.4 |
| 3 | Bauteil C |  | 5d | 2016-01-08 A | 2016-01-14 A | 1 | 100% |  |  |  |  | Einkäufer [60%]; Projektleiter [2%]; Büromaterial [0.1%] | 24.8h | 24.8h | 1,504 | 1,504 |
| 4 | Bauteil A fräsen |  | 8d | 2016-01-20 A | 2016-02-03 | 2 | 75% | 2d | 1d | 0d |  | Mechaniker [80%]; Fräsmaschine; Kühlmittel; Projektleiter [5%]; Büromaterial [0.1%] | 59.2h | 46.4h | 3,244 | 2,732 |
| 5 | Bauteil B hobeln |  | 9d | 2016-01-20 A | 2016-02-12 | 2 | 60% | 3.6d | 4d |  |  | Mechaniker [80%]; Hobelbank; Kühlmittel; Projektleiter [5%]; Büromaterial [0.1%] | 103.6h | 67.12h | 5,612 | 3,817.26 |
| 6 | Bauteil C drehen |  | 8d | 2016-01-15 A | 2016-02-18 A | 3 | 100% |  |  |  |  | Mechaniker [80%]; Drehbank; Kühlmittel; Projektleiter [5%]; Büromaterial [0.1%] | 59.2h | 59.2h | 3,276 | 3,276 |
| 7 | Bauteil D bohren |  | 5d | 2016-01-15 A | 2016-01-21 | 3 | 65% | 1.75d | 26d |  |  | Mechaniker [80%]; Bohrmaschine; Kühlmittel; Projektleiter [5%]; Büromaterial [0.1%] | 74h | 48.1h | 3,932 | 2,555.8 |
| 8 | Bauteil A bohren |  | 5d | 2016-02-04 A | 2016-02-10 | 4 | 20% | 4d | 12d |  |  | Mechaniker [80%]; Bohrmaschine; Kühlmittel; Projektleiter [5%]; Büromaterial [0.1%] | 74h | 14.8h | 3,932 | 786.4 |
| 9 | Gruppe montieren |  | 6d | 2016-02-19 | 2016-02-26 | 5, 6 |  |  | 0d |  |  | Monteur; Schmiermittel; Projektleiter [1%]; Büromaterial [0.1%] | 48.48h |  | 3,412.4 |  |
| 10 | Produkt montieren |  | 1d | 2016-02-29 | 2016-02-29 | 7, 8, 9 |  |  | 0d |  |  | Monteur; Schmiermittel; Projektleiter [1%]; Büromaterial [0.1%] | 8.08h |  | 580.4 |  |
